# Líšnice_2022_11_28

Schedule from MS Project, 2023-03-01 to 2023-09-27.

## Calendars

- Standardní: Mon-Fri 09:00-13:00, 14:00-18:00; Sat-Sun off.

## Schedule

| ID | WBS | Task | Duration | Start | Finish | Predecessors | Total slack | Free slack |
| --- | --- | --- | --- | --- | --- | --- | --- | --- |
| 1 | 1 | **III/0042 Líšnice, rekonstrukce** | 151d | 2023-03-01 | 2023-09-27 |  |  |  |
| 2 | 1.1 | Zahájení realizace stavby | 1d | 2023-03-01 | 2023-03-01 |  | 0d |  |
| 3 | 1.2 | SO 101 - Rekonstrukce komunikace km ZÚ - km 1,020 | 40d | 2023-03-16 | 2023-05-10 | 26 | 20d | 0d |
| 4 | 1.3 | SO 102 - Rekonstrukce komunikace km 1,020 - km 1,140 | 40d | 2023-03-16 | 2023-05-10 | 30, 26 | 10d | 0d |
| 5 | 1.4 | SO 103 - Rekonstrukce komunikace km 1,140 - km 1,480 | 20d | 2023-05-25 | 2023-06-21 | 27, 3, 4 | 10d | 0d |
| 6 | 1.5 | SO 104 - Rekonstrukce komunikace km 1,480 - km 1,720 | 20d | 2023-06-22 | 2023-07-19 | 5, 3, 4 | 40d | 0d |
| 7 | 1.6 | SO 105 - Rekonstrukce komunikace km 1,020 - km 1,140 | 40d | 2023-07-06 | 2023-08-30 | 3, 4, 5, 28 | 20d |  |
| 8 | 1.7 | SO 106 - Rekonstrukce komunikace 1,940 - KÚ | 40d | 2023-07-06 | 2023-08-30 | 28, 3, 4, 5 | 10d | 0d |
| 9 | 1.8 | <NovýSO 106.1 - Oprava povrchu komunikace v km 2,600 - km 3,236 úkol> | 90d | 2023-03-01 | 2023-07-04 |  | 61d |  |
| 10 | 1.9 | SO 120 - Úprava stávajícího sjezdu v km 0,620 | 20d | 2023-04-13 | 2023-05-10 | 3FF | 100d |  |
| 11 | 1.10 | SO 151 - Chodník pro pěší v km 0,500 - 1,080 vlevo | 15d | 2023-04-20 | 2023-05-10 | 3FF | 100d |  |
| 12 | 1.11 | SO 152 - Chodník pro pěší v km 1,120 - 1,300 | 10d | 2023-06-08 | 2023-06-21 | 5FF | 70d |  |
| 13 | 1.12 | SO 153 - Chodník pro pěší v km 1,315 - 1,450 | 10d | 2023-06-08 | 2023-06-21 | 5FF | 70d |  |
| 14 | 1.13 | SO 154 - Úprava parkování v km 1,490 - 1,580 vlevo | 15d | 2023-06-29 | 2023-07-19 | 6FF | 50d |  |
| 15 | 1.14 | SO 155 - Úprava oboustranné zastávky BUS v km 2,680 -2,750 | 15d | 2023-08-10 | 2023-08-30 | 8FF | 20d |  |
| 16 | 1.15 | SO 170.1 (SO 101, 102) - Dopravní značení komunikace III/0042 | 10d | 2023-05-11 | 2023-05-24 | 3 | 90d |  |
| 17 | 1.16 | SO 170.2 (SO 103) - Dopravní značení komunikace III/0042 | 10d | 2023-06-22 | 2023-07-05 | 5 | 60d |  |
| 18 | 1.17 | SO 170.3 (SO 104) - Dopravní značení komunikace III/0042 | 10d | 2023-07-20 | 2023-08-02 | 6 | 40d |  |
| 19 | 1.18 | SO 170.4 (SO 105, 106) - Dopravní značení komunikace III/0042 | 10d | 2023-08-31 | 2023-09-13 | 8 | 10d |  |
| 20 | 1.19 | SO 170.5 - Dopravní značení objízdných tras | 10d | 2023-03-02 | 2023-03-15 | 2 | 140d |  |
| 21 | 1.20 | SO 171.1 - Dopravní značení pro obec Líšnice (SO 103) | 5d | 2023-06-22 | 2023-06-28 | 5 | 65d |  |
| 22 | 1.21 | SO 171.2 - Dopravní značení pro obec Líšnice (SO 104) | 5d | 2023-07-20 | 2023-07-26 | 6 | 45d |  |
| 23 | 1.22 | SO 175 - Dopravně inženýrská opatření | 150d | 2023-03-02 | 2023-09-27 | 2 | 0d |  |
| 24 | 1.23 | SO 181 - Opravy objízdných tras | 20d | 2023-08-31 | 2023-09-27 | 23FF | 0d |  |
| 25 | 1.24 | SO 201 - Rekonstrukce propustku v km 1,460 | 30d | 2023-05-11 | 2023-06-21 | 4 | 70d |  |
| 26 | 1.25 | SO 301 - Dešťová kanalizace v km 0,780 - 1,120 | 10d | 2023-03-02 | 2023-03-15 | 2 | 10d | 0d |
| 27 | 1.26 | SO 302 - Dešťová kanalizace v km 1,120 - 1,320 | 10d | 2023-05-11 | 2023-05-24 | 4 | 10d | 0d |
| 28 | 1.27 | SO 303 - Dešťová kanalizace v km 1,460 - 1,940 | 10d | 2023-06-22 | 2023-07-05 | 5 | 10d | 0d |
| 29 | 1.28 | SO 310 - Odvedení vod v km 1,130 | 10d | 2023-03-02 | 2023-03-15 | 2 | 211d |  |
| 30 | 1.29 | SO 810.1 - Náhradní výsadby a vegetační úpravy (kácení) | 10d | 2023-03-02 | 2023-03-15 | 2 | 10d | 0d |
| 31 | 1.30 | SO 810.2 - Náhradní výsadby a vegetační úpravy (výsadby) | 10d | 2023-08-31 | 2023-09-13 | 8 | 10d |  |
